# STYRENE PARK OFFSITE PROJECT

Schedule from MS Project, 2024-06-05 to 2025-02-05, status date 2024-06-04.

## Calendars

- 1158: Mon-Thu 07:30-13:00, 14:00-16:30; Fri 08:00-12:00, 13:00-17:00; Sat 07:30-13:00, 14:00-16:30; Sun off. Exceptions (off unless hours are given): 2024-07-15 to 2024-07-16 (تاسوعا عاشورا).

## Schedule

| ID | WBS | Task | Type | Duration | Start | Finish | Predecessors | Baseline start | Baseline finish | Baseline duration | Total slack | Free slack | Text1 | Text2 |
| --- | --- | --- | --- | --- | --- | --- | --- | --- | --- | --- | --- | --- | --- | --- |
| 1 | 1 | START | milestone | 0d | 2024-06-05 | 2024-06-05 |  | 2024-06-05 | 2024-06-05 | 0d | 0d |  | 1403/3/16 | 1403/3/16 |
| 2 | 2 | **MILESTONE** |  | 0d | 2024-06-05 | 2024-06-05 |  | 2024-06-05 | 2024-06-05 | 0d | 0d |  | 1403/3/16 | 1403/3/16 |
| 3 | 2.1 | RECEIVE DOCUMENTS | milestone | 0d | 2024-06-05 | 2024-06-05 | 1 | 2024-06-05 | 2024-06-05 | 0d | 0d |  | 1403/3/16 | 1403/3/16 |
| 4 | 2.2 | ADVANCE PAYMENT | milestone | 0d | 2024-06-05 | 2024-06-05 | 1 | 2024-06-05 | 2024-06-05 | 0d | 0d |  | 1403/3/16 | 1403/3/16 |
| 5 | 3 | **ENGINEERING** |  | 60d | 2024-06-05 | 2024-08-15 |  | 2024-06-05 | 2024-08-15 | 60d | 0d |  | 1403/3/16 | 1403/5/25 |
| 6 | 3.1 | **MAIN DOCUMENT** |  | 27d | 2024-06-05 | 2024-07-05 |  | 2024-06-05 | 2024-07-05 | 27d | 0d |  | 1403/3/16 | 1403/4/15 |
| 7 | 3.1.1 | VENDOR PRINT INDEX SCHEDULE (VPIS) |  | 14d | 2024-06-05 | 2024-06-20 | 3, 4 | 2024-06-05 | 2024-06-20 | 14d | 0d |  | 1403/3/16 | 1403/3/31 |
| 8 | 3.1.2 | AIR COOLER THERMAL DATA SHEET |  | 14d | 2024-06-05 | 2024-06-20 | 3, 4 | 2024-06-05 | 2024-06-20 | 14d | 0d |  | 1403/3/16 | 1403/3/31 |
| 9 | 3.1.3 | GENERAL ARRANGEMENT DRAWING |  | 14d | 2024-06-12 | 2024-06-27 | 8FS-8d | 2024-06-12 | 2024-06-27 | 14d | 4d | 0d | 1403/3/23 | 1403/4/7 |
| 10 | 3.1.4 | STEEL STRUCTURE CALCULATION |  | 14d | 2024-06-13 | 2024-06-28 | 8FS-7d | 2024-06-13 | 2024-06-28 | 14d | 33d | 0d | 1403/3/24 | 1403/4/8 |
| 11 | 3.1.5 | TUBE BUNDLE DRAWING |  | 14d | 2024-06-19 | 2024-07-04 | 8FS-8d, 9FS-8d | 2024-06-19 | 2024-07-04 | 14d | 5d | 0d | 1403/3/30 | 1403/4/14 |
| 12 | 3.1.6 | MECHANICAL CALCULATION |  | 14d | 2024-06-20 | 2024-07-05 | 8FS-7d, 9FS-7d | 2024-06-20 | 2024-07-05 | 14d | 4d | 0d | 1403/3/31 | 1403/4/15 |
| 13 | 3.2 | **DETAIL DOCUMENT** |  | 55d | 2024-06-11 | 2024-08-15 |  | 2024-06-11 | 2024-08-15 | 55d | 9d |  | 1403/3/22 | 1403/5/25 |
| 14 | 3.2.1 | BUNDLE FRAME DRAWING |  | 14d | 2024-07-01 | 2024-07-18 | 9FS-5d, 11FS-5d, 12FS-5d | 2024-07-01 | 2024-07-18 | 14d | 4d | 0d | 1403/4/11 | 1403/4/28 |
| 15 | 3.2.2 | FAN DRIVE ASSEMBLY DRAWING |  | 14d | 2024-06-27 | 2024-07-12 | 10FS-2d | 2024-06-27 | 2024-07-12 | 14d | 39d | 6d | 1403/4/7 | 1403/4/22 |
| 16 | 3.2.3 | FAN RING DRAWING |  | 14d | 2024-06-29 | 2024-07-17 | 10 | 2024-06-29 | 2024-07-17 | 14d | 37d | 4d | 1403/4/9 | 1403/4/27 |
| 17 | 3.2.4 | SUPPORT MECHANISM DRAWING |  | 14d | 2024-07-02 | 2024-07-19 | 10FS+2d | 2024-07-02 | 2024-07-19 | 14d | 35d | 2d | 1403/4/12 | 1403/4/29 |
| 18 | 3.2.5 | PLENUM DRAWING |  | 14d | 2024-07-04 | 2024-07-22 | 10FS+4d | 2024-07-04 | 2024-07-22 | 14d | 33d | 0d | 1403/4/14 | 1403/5/1 |
| 19 | 3.2.6 | NAME PLATE DRAWING |  | 14d | 2024-07-31 | 2024-08-15 | 9FS+26d | 2024-07-31 | 2024-08-15 | 14d | 128d | 124d | 1403/5/10 | 1403/5/25 |
| 20 | 3.2.7 | STEEL STRUCTURE DRAWING |  | 14d | 2024-07-03 | 2024-07-20 | 10FS+3d | 2024-07-03 | 2024-07-20 | 14d | 34d | 0d | 1403/4/13 | 1403/4/30 |
| 21 | 3.2.8 | HEADER WALKWAY DRAWING |  | 14d | 2024-07-03 | 2024-07-20 | 10FS+3d | 2024-07-03 | 2024-07-20 | 14d | 34d | 1d | 1403/4/13 | 1403/4/30 |
| 22 | 3.2.9 | LADDER DRAWING |  | 14d | 2024-07-03 | 2024-07-20 | 10FS+3d | 2024-07-03 | 2024-07-20 | 14d | 34d | 1d | 1403/4/13 | 1403/4/30 |
| 23 | 3.2.10 | AXIAL FAN DATA SHEET |  | 14d | 2024-06-11 | 2024-06-26 | 8FS-9d | 2024-06-11 | 2024-06-26 | 14d | 9d | 0d | 1403/3/22 | 1403/4/6 |
| 24 | 3.2.11 | ELECTRICAL MOTOR DATA SHEET |  | 14d | 2024-06-11 | 2024-06-26 | 8FS-9d | 2024-06-11 | 2024-06-26 | 14d | 9d | 0d | 1403/3/22 | 1403/4/6 |
| 25 | 3.2.12 | BELT & PULLEY DATA SHEET |  | 14d | 2024-06-12 | 2024-06-27 | 8FS-8d | 2024-06-12 | 2024-06-27 | 14d | 8d | 0d | 1403/3/23 | 1403/4/7 |
| 26 | 3.2.13 | VIBRATION SWITCH DATA SHEET |  | 14d | 2024-06-14 | 2024-06-29 | 8FS-6d | 2024-06-14 | 2024-06-29 | 14d | 6d |  | 1403/3/25 | 1403/4/9 |

| ID | WBS | Task | Duration | Start | Finish | Predecessors | Baseline start | Baseline finish | Baseline duration | Total slack | Free slack | Text1 | Text2 |
| --- | --- | --- | --- | --- | --- | --- | --- | --- | --- | --- | --- | --- | --- |
| 27 | 3.3 | **GENERAL DOCUMENT** | 44d | 2024-06-21 | 2024-08-13 |  | 2024-06-21 | 2024-08-13 | 44d | 0d |  | 1403/4/1 | 1403/5/23 |
| 28 | 3.3.1 | ELECTRICAL LOAD LIST | 14d | 2024-06-24 | 2024-07-09 | 24FS-3d, 23FS-3d | 2024-06-24 | 2024-07-09 | 14d | 169d |  | 1403/4/4 | 1403/4/19 |
| 29 | 3.3.2 | INSPECTION TEST PLAN (ITP) | 14d | 2024-06-21 | 2024-07-06 | 8 | 2024-06-21 | 2024-07-06 | 14d | 27d | 0d | 1403/4/1 | 1403/4/16 |
| 30 | 3.3.3 | WPS & PQR FOR PRESSURE PART AND STRUCTURE PART | 14d | 2024-06-29 | 2024-07-17 | 29FS-7d | 2024-06-29 | 2024-07-17 | 14d | 27d | 0d | 1403/4/9 | 1403/4/27 |
| 31 | 3.3.4 | NDT PROCEDURE & WELD/NDT MAP | 14d | 2024-07-29 | 2024-08-13 | 30FS+9d | 2024-07-29 | 2024-08-13 | 14d | 84d | 80d | 1403/5/8 | 1403/5/23 |
| 32 | 3.3.5 | SURFACE BLASTING & PAINTING & GALVANIZING SPECIFICATION AND INSPECTIONPROCEDURE | 14d | 2024-07-02 | 2024-07-19 | 29FS-5d | 2024-07-02 | 2024-07-19 | 14d | 144d | 71d | 1403/4/12 | 1403/4/29 |
| 33 | 3.3.6 | PWHT PROCEDURE | 14d | 2024-07-03 | 2024-07-20 | 29FS-4d | 2024-07-03 | 2024-07-20 | 14d | 129d | 125d | 1403/4/13 | 1403/4/30 |
| 34 | 3.3.7 | TUBE EXPANDING PROCEDURE | 14d | 2024-07-05 | 2024-07-23 | 11 | 2024-07-05 | 2024-07-23 | 14d | 148d | 144d | 1403/4/15 | 1403/5/2 |
| 35 | 3.3.8 | PACKING & MARKING PROCEDURE | 14d | 2024-07-08 | 2024-07-25 | 29 | 2024-07-08 | 2024-07-25 | 14d | 156d | 77d | 1403/4/18 | 1403/5/4 |
| 36 | 3.3.9 | HYDROSTATIC TEST PROCEDURE | 14d | 2024-07-13 | 2024-07-31 | 29FS+5d | 2024-07-13 | 2024-07-31 | 14d | 148d | 144d | 1403/4/23 | 1403/5/10 |
| 37 | 3.3.10 | N2 PURGING PROCEDURE | 14d | 2024-07-17 | 2024-08-01 | 29FS+6d | 2024-07-17 | 2024-08-01 | 14d | 140d | 136d | 1403/4/27 | 1403/5/11 |
| 38 | 3.3.11 | WELDER QUALIFICATION TEST CERTIFICATE | 14d | 2024-07-25 | 2024-08-09 | 30FS+6d | 2024-07-25 | 2024-08-09 | 14d | 27d | 3d | 1403/5/4 | 1403/5/19 |
| 39 | 3.3.12 | SHOP RUN TEST PROCEDURE | 14d | 2024-07-17 | 2024-08-01 | 11FS+8d | 2024-07-17 | 2024-08-01 | 14d | 150d |  | 1403/4/27 | 1403/5/11 |
| 40 | 3.3.13 | INSTALLATION , OPERATION & MAINTANENCE (MANUAL) | 14d | 2024-07-29 | 2024-08-13 | 8FS+30d | 2024-07-29 | 2024-08-13 | 14d | 141d |  | 1403/5/8 | 1403/5/23 |
| 41 | 3.3.14 | COMMISSIONING SPARE PART LIST | 14d | 2024-07-12 | 2024-07-30 | 11FS+6d, 23FS+6d, 24FS+6d, 25FS+6d | 2024-07-12 | 2024-07-30 | 14d | 140d | 0d | 1403/4/22 | 1403/5/9 |
| 42 | 3.3.15 | 2-YEARS SPARE PART LIST | 14d | 2024-07-29 | 2024-08-13 | 11FS-2d, 24FS-2d, 25FS-2d, 23FS-2d, 41FS-2d | 2024-07-29 | 2024-08-13 | 14d | 140d |  | 1403/5/8 | 1403/5/23 |
| 43 | 3.3.16 | SPECIAL TOOLS LIST | 14d | 2024-07-19 | 2024-08-03 | 11FS+10d | 2024-07-19 | 2024-08-03 | 14d | 148d |  | 1403/4/29 | 1403/5/13 |
| 44 | 3.3.17 | SUB VENDOR LIST | 14d | 2024-06-21 | 2024-07-06 | 8, 7 | 2024-06-21 | 2024-07-06 | 14d | 0d |  | 1403/4/1 | 1403/4/16 |
| 45 | 3.3.18 | TIME SCHEDULE | 14d | 2024-06-27 | 2024-07-12 | 7FS+5d | 2024-06-27 | 2024-07-12 | 14d | 165d |  | 1403/4/7 | 1403/4/22 |
| 46 | 3.3.19 | LUBRICANT CHART | 14d | 2024-06-27 | 2024-07-12 | 23, 24 | 2024-06-27 | 2024-07-12 | 14d | 165d |  | 1403/4/7 | 1403/4/22 |
| 47 | 3.3.20 | PACKING LIST | 14d | 2024-07-22 | 2024-08-06 | 29FS+10d | 2024-07-22 | 2024-08-06 | 14d | 146d | 67d | 1403/5/1 | 1403/5/16 |
| 48 | 4 | **PROCUREMENT** | 184d | 2024-06-20 | 2025-01-22 |  | 2024-06-20 | 2025-01-22 | 184d | 0d |  | 1403/3/31 | 1403/11/3 |
| 49 | 4.1 | **LOCAL MATERIAL** | 104d | 2024-06-28 | 2024-10-29 |  | 2024-06-28 | 2024-10-29 | 104d | 8d |  | 1403/4/8 | 1403/8/8 |
| 50 | 4.1.1 | PLATE FOR HEADER | 20d | 2024-07-08 | 2024-08-01 | 11, 12, 4, 44 | 2024-07-08 | 2024-08-01 | 20d | 11d | 0d | 1403/4/18 | 1403/5/11 |
| 51 | 4.1.2 | PLATE & PROFIL FOR MAIN STRUCTURES PARTS | 20d | 2024-07-22 | 2024-08-13 | 4, 20 | 2024-07-22 | 2024-08-13 | 20d | 79d | 0d | 1403/5/1 | 1403/5/23 |
| 52 | 4.1.3 | PLATE & PROFIL FOR OTHERS STRUCTURES | 20d | 2024-08-21 | 2024-09-12 | 20FS+25d, 4FS+25d, 15FS+25d, 16FS+25d, 17FS+25d, 18FS+25d, 21FS+25d, 22FS+25d | 2024-08-21 | 2024-09-12 | 20d | 33d | 0d | 1403/5/31 | 1403/6/22 |
| 53 | 4.1.4 | PLATE & PROFIL FOR BUNDLE FRAME | 20d | 2024-08-23 | 2024-09-14 | 14FS+30d, 4FS+30d | 2024-08-23 | 2024-09-14 | 20d | 4d | 0d | 1403/6/2 | 1403/6/24 |
| 54 | 4.1.5 | PIPE | 20d | 2024-09-16 | 2024-10-08 | 11FS+60d, 4FS+60d | 2024-09-16 | 2024-10-08 | 20d | 6d | 2d | 1403/6/26 | 1403/7/17 |
| 55 | 4.1.6 | GASKET | 20d | 2024-08-13 | 2024-09-04 | 11FS+30d, 12FS+30d, 4FS+30d | 2024-08-13 | 2024-09-04 | 20d | 111d | 107d | 1403/5/23 | 1403/6/14 |
| 56 | 4.1.7 | BOLT&NUT | 20d | 2024-08-26 | 2024-09-17 | 11FS+30d, 20FS+30d, 4FS+30d | 2024-08-26 | 2024-09-17 | 20d | 100d | 96d | 1403/6/5 | 1403/6/27 |
| 57 | 4.1.8 | PLUG | 20d | 2024-08-12 | 2024-09-03 | 11FS+30d, 4FS+30d | 2024-08-12 | 2024-09-03 | 20d | 112d | 108d | 1403/5/22 | 1403/6/13 |
| 58 | 4.1.9 | PAINT | 20d | 2024-09-04 | 2024-09-26 | 11FS+50d, 4FS+50d | 2024-09-04 | 2024-09-26 | 20d | 85d | 81d | 1403/6/14 | 1403/7/5 |

| ID | WBS | Task | Duration | Start | Finish | Predecessors | Baseline start | Baseline finish | Baseline duration | Total slack | Free slack | Text1 | Text2 |
| --- | --- | --- | --- | --- | --- | --- | --- | --- | --- | --- | --- | --- | --- |
| 59 | 4.1.10 | **FLANGES** | 84d | 2024-07-03 | 2024-10-10 |  | 2024-07-03 | 2024-10-10 | 84d | 4d |  | 1403/4/13 | 1403/7/19 |
| 60 | 4.1.10.1 | FLANGES ( PO ) | 14d | 2024-07-03 | 2024-07-20 | 4, 12FS-3d | 2024-07-03 | 2024-07-20 | 14d | 4d | 0d | 1403/4/13 | 1403/4/30 |
| 61 | 4.1.10.2 | FLANGES (MANUFACTURING) | 60d | 2024-07-22 | 2024-09-28 | 60 | 2024-07-22 | 2024-09-28 | 60d | 4d | 0d | 1403/5/1 | 1403/7/7 |
| 62 | 4.1.10.3 | FLANGES ( DELIVERY ) | 10d | 2024-09-30 | 2024-10-10 | 61 | 2024-09-30 | 2024-10-10 | 10d | 4d | 0d | 1403/7/9 | 1403/7/19 |
| 63 | 4.1.11 | **PULLEY** | 104d | 2024-06-28 | 2024-10-29 |  | 2024-06-28 | 2024-10-29 | 104d | 73d |  | 1403/4/8 | 1403/8/8 |
| 64 | 4.1.11.1 | PULLEY ( PO ) | 14d | 2024-06-28 | 2024-07-13 | 25, 4 | 2024-06-28 | 2024-07-13 | 14d | 73d | 0d | 1403/4/8 | 1403/4/23 |
| 65 | 4.1.11.2 | PULLEY (MANUFACTURING) | 60d | 2024-07-17 | 2024-09-24 | 64 | 2024-07-17 | 2024-09-24 | 60d | 73d | 0d | 1403/4/27 | 1403/7/3 |
| 66 | 4.1.11.3 | PULLEY ( DELIVERY ) | 30d | 2024-09-25 | 2024-10-29 | 65 | 2024-09-25 | 2024-10-29 | 30d | 73d |  | 1403/7/4 | 1403/8/8 |
| 67 | 4.1.12 | **ALUM.TUBE** | 104d | 2024-06-28 | 2024-10-29 |  | 2024-06-28 | 2024-10-29 | 104d | 59d |  | 1403/4/8 | 1403/8/8 |
| 68 | 4.1.12.1 | ALUM.TUBE ( PO ) | 14d | 2024-06-28 | 2024-07-13 | 9, 4 | 2024-06-28 | 2024-07-13 | 14d | 59d | 0d | 1403/4/8 | 1403/4/23 |
| 69 | 4.1.12.2 | ALUM.TUBE (MANUFACTURING) | 60d | 2024-07-17 | 2024-09-24 | 68 | 2024-07-17 | 2024-09-24 | 60d | 59d | 0d | 1403/4/27 | 1403/7/3 |
| 70 | 4.1.12.3 | ALUM.TUBE ( DELIVERY) | 30d | 2024-09-25 | 2024-10-29 | 69 | 2024-09-25 | 2024-10-29 | 30d | 59d | 53d | 1403/7/4 | 1403/8/8 |
| 71 | 4.2 | **FOREIGN MATERIAL** | 184d | 2024-06-20 | 2025-01-22 |  | 2024-06-20 | 2025-01-22 | 184d | 0d |  | 1403/3/31 | 1403/11/3 |
| 72 | 4.2.1 | **BASE TUBE** | 164d | 2024-06-20 | 2024-12-30 |  | 2024-06-20 | 2024-12-30 | 164d | 6d |  | 1403/3/31 | 1403/10/10 |
| 73 | 4.2.1.1 | BASE TUBE( PO ) | 14d | 2024-06-20 | 2024-07-05 | 9FS-7d, 4 | 2024-06-20 | 2024-07-05 | 14d | 6d | 0d | 1403/3/31 | 1403/4/15 |
| 74 | 4.2.1.2 | BASE TUBE (MANUFACTURING) | 60d | 2024-07-06 | 2024-09-16 | 73 | 2024-07-06 | 2024-09-16 | 60d | 6d | 0d | 1403/4/16 | 1403/6/26 |
| 75 | 4.2.1.3 | BASE TUBE (DELIVERY ) | 90d | 2024-09-17 | 2024-12-30 | 74 | 2024-09-17 | 2024-12-30 | 90d | 6d | 0d | 1403/6/27 | 1403/10/10 |
| 76 | 4.2.2 | **MOTOR** | 169d | 2024-07-08 | 2025-01-22 |  | 2024-07-08 | 2025-01-22 | 169d | 0d |  | 1403/4/18 | 1403/11/3 |
| 77 | 4.2.2.1 | MOTOR ( PO ) | 14d | 2024-07-08 | 2024-07-25 | 24, 4, 44 | 2024-07-08 | 2024-07-25 | 14d | 0d |  | 1403/4/18 | 1403/5/4 |
| 78 | 4.2.2.2 | MOTOR (MANUFACTURING) | 55d | 2024-07-26 | 2024-09-27 | 77 | 2024-07-26 | 2024-09-27 | 55d | 0d |  | 1403/5/5 | 1403/7/6 |
| 79 | 4.2.2.3 | MOTOR ( DELIVERY ) | 100d | 2024-09-28 | 2025-01-22 | 78 | 2024-09-28 | 2025-01-22 | 100d | 0d |  | 1403/7/7 | 1403/11/3 |
| 80 | 4.2.3 | **FAN** | 169d | 2024-07-08 | 2025-01-22 |  | 2024-07-08 | 2025-01-22 | 169d | 0d |  | 1403/4/18 | 1403/11/3 |
| 81 | 4.2.3.1 | FAN( PO) | 14d | 2024-07-08 | 2024-07-25 | 23, 4, 44 | 2024-07-08 | 2024-07-25 | 14d | 0d |  | 1403/4/18 | 1403/5/4 |
| 82 | 4.2.3.2 | FAN (MANUFACTURING) | 55d | 2024-07-26 | 2024-09-27 | 81 | 2024-07-26 | 2024-09-27 | 55d | 0d |  | 1403/5/5 | 1403/7/6 |
| 83 | 4.2.3.3 | FAN ( DELIVERY) | 100d | 2024-09-28 | 2025-01-22 | 82 | 2024-09-28 | 2025-01-22 | 100d | 0d |  | 1403/7/7 | 1403/11/3 |

| ID | WBS | Task | Duration | Start | Finish | Predecessors | Baseline start | Baseline finish | Baseline duration | Total slack | Free slack | Text1 | Text2 |
| --- | --- | --- | --- | --- | --- | --- | --- | --- | --- | --- | --- | --- | --- |
| 84 | 4.2.4 | **VIBRATION SWITCH** | 169d | 2024-07-08 | 2025-01-22 |  | 2024-07-08 | 2025-01-22 | 169d | 0d |  | 1403/4/18 | 1403/11/3 |
| 85 | 4.2.4.1 | VIBRATION SWITCH ( PO ) | 14d | 2024-07-08 | 2024-07-25 | 26, 4, 44 | 2024-07-08 | 2024-07-25 | 14d | 0d |  | 1403/4/18 | 1403/5/4 |
| 86 | 4.2.4.2 | VIBRATION SWITCH (MANUFACTURING) | 55d | 2024-07-26 | 2024-09-27 | 85 | 2024-07-26 | 2024-09-27 | 55d | 0d |  | 1403/5/5 | 1403/7/6 |
| 87 | 4.2.4.3 | VIBRATION SWITCH ( DELIVERY ) | 100d | 2024-09-28 | 2025-01-22 | 86 | 2024-09-28 | 2025-01-22 | 100d | 0d |  | 1403/7/7 | 1403/11/3 |
| 88 | 4.2.5 | **BELT** | 169d | 2024-07-08 | 2025-01-22 |  | 2024-07-08 | 2025-01-22 | 169d | 0d |  | 1403/4/18 | 1403/11/3 |
| 89 | 4.2.5.1 | BELT( PO ) | 14d | 2024-07-08 | 2024-07-25 | 25, 4, 44 | 2024-07-08 | 2024-07-25 | 14d | 0d |  | 1403/4/18 | 1403/5/4 |
| 90 | 4.2.5.2 | BELT (MANUFACTURING) | 55d | 2024-07-26 | 2024-09-27 | 89 | 2024-07-26 | 2024-09-27 | 55d | 0d |  | 1403/5/5 | 1403/7/6 |
| 91 | 4.2.5.3 | BELT ( DELIVERY ) | 100d | 2024-09-28 | 2025-01-22 | 90 | 2024-09-28 | 2025-01-22 | 100d | 0d |  | 1403/7/7 | 1403/11/3 |
| 92 | 5 | **MANUFACTURING** | 142d | 2024-08-06 | 2025-01-17 |  | 2024-08-06 | 2025-01-17 | 142d | 4d |  | 1403/5/16 | 1403/10/28 |
| 93 | 5.1 | **FABRICATION** | 136d | 2024-08-06 | 2025-01-10 |  | 2024-08-06 | 2025-01-10 | 136d | 6d |  | 1403/5/16 | 1403/10/21 |
| 94 | 5.1.1 | **HEADER** | 126d | 2024-08-06 | 2024-12-30 |  | 2024-08-06 | 2024-12-30 | 126d | 4d |  | 1403/5/16 | 1403/10/10 |
| 95 | 5.1.1.1 | CUTTING | 30d | 2024-08-06 | 2024-09-09 | 50FS+3d | 2024-08-06 | 2024-09-09 | 30d | 11d | 0d | 1403/5/16 | 1403/6/19 |
| 96 | 5.1.1.2 | PRIMERY FITUP HEADER | 30d | 2024-08-17 | 2024-09-20 | 95FS-20d | 2024-08-17 | 2024-09-20 | 30d | 11d | 0d | 1403/5/27 | 1403/6/30 |
| 97 | 5.1.1.3 | HEADERS INTERNAL WELDING | 30d | 2024-08-29 | 2024-10-02 | 96FS-20d, 38 | 2024-08-29 | 2024-10-02 | 30d | 11d | 0d | 1403/6/8 | 1403/7/11 |
| 98 | 5.1.1.4 | HEADERS EXTERNAL WELDING | 30d | 2024-09-16 | 2024-10-19 | 97FS-15d, 38 | 2024-09-16 | 2024-10-19 | 30d | 11d | 0d | 1403/6/26 | 1403/7/28 |
| 99 | 5.1.1.5 | HEADERS DRILLING | 30d | 2024-10-03 | 2024-11-06 | 98FS-15d | 2024-10-03 | 2024-11-06 | 30d | 11d | 0d | 1403/7/12 | 1403/8/16 |
| 100 | 5.1.1.6 | HEADERS END PLATE FITUP & WELDING | 30d | 2024-10-15 | 2024-11-18 | 99FS-20d, 38 | 2024-10-15 | 2024-11-18 | 30d | 11d | 7d | 1403/7/24 | 1403/8/28 |
| 101 | 5.1.1.7 | NOZZLE FLANGES PREPARATION | 30d | 2024-10-11 | 2024-11-14 | 62, 54 | 2024-10-11 | 2024-11-14 | 30d | 4d | 0d | 1403/7/20 | 1403/8/24 |
| 102 | 5.1.1.8 | NOZZLE FLANGES FITUP / WELDING IN HEADERS | 25d | 2024-11-15 | 2024-12-13 | 100FS-10d, 101, 31, 38 | 2024-11-15 | 2024-12-13 | 25d | 4d | 0d | 1403/8/25 | 1403/9/23 |
| 103 | 5.1.1.9 | NDT TEST | 25d | 2024-11-15 | 2024-12-13 | 102SS, 97 | 2024-11-15 | 2024-12-13 | 25d | 4d | 0d | 1403/8/25 | 1403/9/23 |
| 104 | 5.1.1.10 | PWHT | 14d | 2024-12-14 | 2024-12-30 | 103, 33 | 2024-12-14 | 2024-12-30 | 14d | 4d | 0d | 1403/9/24 | 1403/10/10 |
| 105 | 5.1.2 | **BUNDLE FRAME** | 84d | 2024-09-24 | 2024-12-30 |  | 2024-09-24 | 2024-12-30 | 84d | 4d |  | 1403/7/3 | 1403/10/10 |
| 106 | 5.1.2.1 | CUTTING BUNDLE FRAMES | 30d | 2024-09-24 | 2024-10-28 | 53FS+7d | 2024-09-24 | 2024-10-28 | 30d | 4d | 0d | 1403/7/3 | 1403/8/7 |
| 107 | 5.1.2.2 | FITUP / WELDING BUNDLE FRAMES | 39d | 2024-11-15 | 2024-12-30 | 106FS+15d | 2024-11-15 | 2024-12-30 | 39d | 4d | 0d | 1403/8/25 | 1403/10/10 |

| ID | WBS | Task | Duration | Start | Finish | Predecessors | Baseline start | Baseline finish | Baseline duration | Total slack | Free slack | Text1 | Text2 |
| --- | --- | --- | --- | --- | --- | --- | --- | --- | --- | --- | --- | --- | --- |
| 108 | 5.1.3 | **STEEL STRUCTURES** | 96d | 2024-08-14 | 2024-12-03 |  | 2024-08-14 | 2024-12-03 | 96d | 33d |  | 1403/5/24 | 1403/9/13 |
| 109 | 5.1.3.1 | MAIN STRUCTURES STEEL STRUCTURES FABRICATION | 50d | 2024-08-14 | 2024-10-10 | 51, 38 | 2024-08-14 | 2024-10-10 | 50d | 79d | 0d | 1403/5/24 | 1403/7/19 |
| 110 | 5.1.3.2 | OTHER STRUCTURES STEEL STRUCTURES FABRICATION | 70d | 2024-09-13 | 2024-12-03 | 52, 38 | 2024-09-13 | 2024-12-03 | 70d | 33d | 0d | 1403/6/23 | 1403/9/13 |
| 111 | 5.1.4 | **FIN TUBE** | 10d | 2024-12-31 | 2025-01-10 |  | 2024-12-31 | 2025-01-10 | 10d | 6d |  | 1403/10/11 | 1403/10/21 |
| 112 | 5.1.4.1 | FIN TUBE FABRICATION | 10d | 2024-12-31 | 2025-01-10 | 70, 75 | 2024-12-31 | 2025-01-10 | 10d | 6d | 2d | 1403/10/11 | 1403/10/21 |
| 113 | 5.2 | **COATING** | 76d | 2024-10-11 | 2025-01-07 |  | 2024-10-11 | 2025-01-07 | 76d | 10d |  | 1403/7/20 | 1403/10/18 |
| 114 | 5.2.1 | HEADERS COATING | 7d | 2024-12-31 | 2025-01-07 | 104, 58, 32 | 2024-12-31 | 2025-01-07 | 7d | 4d | 0d | 1403/10/11 | 1403/10/18 |
| 115 | 5.2.2 | BUNDLE FRAMES COATING | 7d | 2024-12-31 | 2025-01-07 | 107, 32 | 2024-12-31 | 2025-01-07 | 7d | 4d | 0d | 1403/10/11 | 1403/10/18 |
| 116 | 5.2.3 | MAIN STRUCTURES COATING | 7d | 2024-10-11 | 2024-10-18 | 109, 32 | 2024-10-11 | 2024-10-18 | 7d | 79d | 0d | 1403/7/20 | 1403/7/27 |
| 117 | 5.2.4 | OTHER STRUCTURESCOATING | 7d | 2024-12-04 | 2024-12-11 | 110, 32 | 2024-12-04 | 2024-12-11 | 7d | 33d | 0d | 1403/9/14 | 1403/9/21 |
| 118 | 5.3 | **ASSEMBLING OF TUBE BUNDLE** | 7d | 2025-01-08 | 2025-01-15 |  | 2025-01-08 | 2025-01-15 | 7d | 4d |  | 1403/10/19 | 1403/10/26 |
| 119 | 5.3.1 | ASSEMBLING OF TUBE BUNDLE PARTS | 7d | 2025-01-08 | 2025-01-15 | 112FS-5d, 114, 115, 55, 56, 19, 57, 34, 37 | 2025-01-08 | 2025-01-15 | 7d | 4d | 0d | 1403/10/19 | 1403/10/26 |
| 120 | 5.4 | **TESTS** | 7d | 2025-01-10 | 2025-01-17 |  | 2025-01-10 | 2025-01-17 | 7d | 4d |  | 1403/10/21 | 1403/10/28 |
| 121 | 5.4.1 | HYDRO TESTS | 7d | 2025-01-10 | 2025-01-17 | 119FS-5d, 36FS-5d | 2025-01-10 | 2025-01-17 | 7d | 4d | 0d | 1403/10/21 | 1403/10/28 |
| 122 | 6 | **INSPECTION** | 86d | 2024-10-19 | 2025-01-27 |  | 2024-10-19 | 2025-01-27 | 86d | 0d |  | 1403/7/28 | 1403/11/8 |
| 123 | 6.1 | MAIN STRUCTURES | 4d | 2024-10-19 | 2024-10-23 | 116 | 2024-10-19 | 2024-10-23 | 4d | 79d | 0d | 1403/7/28 | 1403/8/2 |
| 124 | 6.2 | OTHER STRUCTURES | 4d | 2024-12-12 | 2024-12-16 | 117 | 2024-12-12 | 2024-12-16 | 4d | 33d | 0d | 1403/9/22 | 1403/9/26 |
| 125 | 6.3 | TUBE BUNDLE | 4d | 2025-01-18 | 2025-01-22 | 121 | 2025-01-18 | 2025-01-22 | 4d | 4d | 0d | 1403/10/29 | 1403/11/3 |
| 126 | 6.4 | MACHINERY EQUIPMENT & INSTRUMENT PARTS | 4d | 2025-01-23 | 2025-01-27 | 79, 83, 87, 91, 66 | 2025-01-23 | 2025-01-27 | 4d | 0d |  | 1403/11/4 | 1403/11/8 |
| 127 | 7 | **PACKING & MARKING & TRANSPORT TO THE SITE** | 83d | 2024-10-24 | 2025-01-28 |  | 2024-10-24 | 2025-01-28 | 83d | 0d |  | 1403/8/3 | 1403/11/9 |
| 128 | 7.1 | MAIN STRUCTURES | 4d | 2024-10-24 | 2024-10-28 | 123, 35, 47 | 2024-10-24 | 2024-10-28 | 4d | 79d |  | 1403/8/3 | 1403/8/7 |
| 129 | 7.2 | OTHER STRUCTURES | 4d | 2024-12-17 | 2024-12-20 | 124, 35, 47 | 2024-12-17 | 2024-12-20 | 4d | 33d |  | 1403/9/27 | 1403/9/30 |
| 130 | 7.3 | TUBE BUNDLE | 4d | 2025-01-20 | 2025-01-23 | 125FS-3d, 35, 47 | 2025-01-20 | 2025-01-23 | 4d | 4d |  | 1403/11/1 | 1403/11/4 |
| 131 | 7.4 | MACHINERY EQUIPMENT & INSTRUMENT PARTS | 4d | 2025-01-24 | 2025-01-28 | 126FS-3d, 35FS-3d, 47FS-3d | 2025-01-24 | 2025-01-28 | 4d | 0d |  | 1403/11/5 | 1403/11/9 |

| ID | WBS | Task | Type | Duration | Start | Finish | Predecessors | Baseline start | Baseline finish | Baseline duration | Total slack | Text1 | Text2 |
| --- | --- | --- | --- | --- | --- | --- | --- | --- | --- | --- | --- | --- | --- |
| 132 | 8 | **FINAL BOOK** |  | 11d | 2025-01-24 | 2025-02-05 |  | 2025-01-24 | 2025-02-05 | 11d | 0d | 1403/11/5 | 1403/11/17 |
| 133 | 8.1 | FINAL DATA BOOK INDEX |  | 11d | 2025-01-24 | 2025-02-05 | 128FS-4d, 129FS-4d, 130FS-4d, 131FS-4d, 39, 43, 42, 45, 46 | 2025-01-24 | 2025-02-05 | 11d | 0d | 1403/11/5 | 1403/11/17 |
| 134 | 8.2 | FINAL DATA BOOK |  | 10d | 2025-01-25 | 2025-02-05 | 133FS-10d, 28, 40 | 2025-01-25 | 2025-02-05 | 10d | 0d | 1403/11/6 | 1403/11/17 |
| 135 | 9 | FINISH | milestone | 0d | 2025-02-05 | 2025-02-05 | 134 | 2025-02-05 | 2025-02-05 | 0d | 0d | 1403/11/17 | 1403/11/17 |
